# Vorlage_drucken

Schedule from MS Project, 2011-01-12 to 2011-01-24, costs in €.

## Calendars

- Standard: Mon-Fri 08:00-12:00, 13:00-17:00; Sat-Sun off. Exceptions (off unless hours are given): 2011-01-21 14:00-24:00 (Tag der Feier).

## Resources

| Resource | Cost per use |
| --- | --- |
| Chef |  |
| Verwaltung |  |
| Catering |  |
| AG „Taumel“ | 2900 |
| Octopus-Reinigung |  |
| Hausdruckerei | 530 |
| Essen | 2400 |

## Schedule

| ID | WBS | Task | Type | Duration | Start | Finish | Predecessors | Total slack | Free slack | Constraint | Resources | Work | Cost |
| --- | --- | --- | --- | --- | --- | --- | --- | --- | --- | --- | --- | --- | --- |
| 1 | 1 | **Jubiläum** |  | 8.38d | 2011-01-12 08:00 | 2011-01-24 09:00 |  | 0d |  |  |  | 125.25h | 3,430 |
| 2 | 1.1 | **Vorbereitung** |  | 6d | 2011-01-12 08:00 | 2011-01-19 17:00 |  | 1.06d |  |  |  | 72h | 530 |
| 3 | 1.1.1 | Start Vorbereitung | milestone | 0d | 2011-01-12 08:00 | 2011-01-12 08:00 |  | 1.06d | 0d |  |  |  |  |
| 4 | 1.1.2 | Gästeliste fertigen |  | 1d | 2011-01-12 08:00 | 2011-01-12 17:00 | 3 | 1.06d | 0d | start no earlier than 2011-01-10 08:00 | Verwaltung [200%] | 16h |  |
| 5 | 1.1.3 | Ablauf beschließen |  | 1d | 2011-01-13 08:00 | 2011-01-13 17:00 | 4 | 1.06d | 0d |  | Verwaltung [200%] | 16h |  |
| 6 | 1.1.4 | Beköstigung planen |  | 1d | 2011-01-14 08:00 | 2011-01-14 17:00 | 5 | 1.06d | 0d |  | Verwaltung [200%] | 16h |  |
| 7 | 1.1.5 | Einladung drucken |  | 1.5d | 2011-01-17 08:00 | 2011-01-18 12:00 | 6 | 1.06d | 0d |  | Hausdruckerei | 12h | 530 |
| 8 | 1.1.6 | Unterhaltung arrangieren |  | 0.5d | 2011-01-18 13:00 | 2011-01-18 17:00 | 7 | 1.06d | 0d |  | Verwaltung | 4h |  |
| 9 | 1.1.7 | Cateringservice verpflichten |  | 0.5d | 2011-01-19 08:00 | 2011-01-19 12:00 | 8 | 1.06d | 0d |  | Verwaltung | 4h |  |
| 10 | 1.1.8 | Reinigungsfirma einweisen |  | 0.5d | 2011-01-19 13:00 | 2011-01-19 17:00 | 9 | 1.06d | 0d |  | Verwaltung | 4h |  |
| 11 | 1.1.9 | Abschluss Vorbereitung | milestone | 0d | 2011-01-19 17:00 | 2011-01-19 17:00 | 10 | 1.06d | 1d |  |  |  |  |
| 12 | 1.2 | **Feier** |  | 0.88d | 2011-01-21 14:00 | 2011-01-21 21:00 |  | 0.06d |  |  |  | 41.25h | 2,900 |
| 13 | 1.2.1 | Beginn Feier | milestone | 0d | 2011-01-21 14:00 | 2011-01-21 14:00 | 11 | 0.06d | 0d | start no earlier than 2011-01-21 14:00 |  |  |  |
| 14 | 1.2.2 | Beköstigung |  | 6h | 2011-01-21 14:00 | 2011-01-21 21:00 | 13 | 0.06d | 0d |  | Catering [600%] | 36h |  |
| 15 | 1.2.3 | Rede Chef |  | 15min | 2011-01-21 15:00 | 2011-01-21 15:15 | 14SS+1h | 0.16d | 0d |  | Chef | 0.25h |  |
| 16 | 1.2.4 | Unterhaltung |  | 5h | 2011-01-21 15:15 | 2011-01-21 20:15 | 15 | 0.16d | 0.09d |  | AG „Taumel“ | 5h | 2,900 |
| 17 | 1.2.5 | Ende Feier | milestone | 0d | 2011-01-21 21:00 | 2011-01-21 21:00 | 16, 14 | 0.06d | 0d |  |  |  |  |
| 18 | 1.3 | **Nacharbeiten** |  | 0.31d | 2011-01-21 21:00 | 2011-01-21 23:30 |  | 0.06d |  |  |  | 10h |  |
| 19 | 1.3.1 | Abräumen und Transport |  | 1.5h | 2011-01-21 21:00 | 2011-01-21 22:30 | 17 | 0.06d | 0d |  | Catering [600%] | 9h |  |
| 20 | 1.3.2 | Reinigung |  | 1h | 2011-01-21 22:30 | 2011-01-21 23:30 | 19 | 0.06d | 0d |  | Octopus-Reinigung | 1h |  |
| 21 | 1.3.3 | Saal bereit zur Übergabe | milestone | 0d | 2011-01-21 23:30 | 2011-01-21 23:30 | 20 | 0.06d |  |  |  |  |  |
| 22 | 1.4 | Auswertung |  | 1h | 2011-01-24 08:00 | 2011-01-24 09:00 | 21 | 0d |  | start no earlier than 2011-01-24 08:00 | Verwaltung; Chef | 2h |  |
